# Habitat2

How a schedule from MS Project changed from version to version. A marks actual dates.

## Version 1 (saved 2008-08-04)

| ID | WBS | Task | Duration | Start | Finish | Total float | Constraint |
| --- | --- | --- | --- | --- | --- | --- | --- |
| 1 | 1 | **Map control decorations** | 128.62d | 2008-08-27 | 2009-02-23 | 0d |  |
| 2 |  | North / south arrow | 0.91d | 2008-08-27 | 2008-08-27 | 127.72d | start no earlier than 2008-08-27 |
| 3 |  | Cross-sectional profiles | 3.64d | 2008-08-28 | 2008-09-02 | 123.99d | start no earlier than 2008-08-28 |
| 4 |  | Scale | 3d | 2008-09-02 | 2008-09-05 | 120.97d | start no earlier than 2008-09-02 |
| 5 |  | Classificatie aanpassen (gui dialog) | 10d | 2009-02-09 | 2009-02-23 | 0d | start no earlier than 2009-02-09 |
| 6 |  | Opslaan en ophalen van classificatie gegevens | 4d | 2009-02-16 | 2009-02-19 | 1.62d | start no earlier than 2009-02-16 |
| 7 | 2 | **Conversie applicatie voor kaartlagen (?)** | 13d | 2009-01-21 | 2009-02-09 | 10d |  |
| 8 |  | Uitzoeken wat werkt en niet werkt voor Resample | 2d | 2009-01-21 | 2009-01-23 | 21d | start no earlier than 2009-01-21 |
| 9 |  | Dummy proef maken | 3d | 2009-01-23 | 2009-01-28 | 18d | start no earlier than 2009-01-23 |
| 10 |  | Bug fixes + overig | 8d | 2009-01-28 | 2009-02-09 | 10d | start no earlier than 2009-01-28 |
| 11 | 3 | **DelftShell upgrade** | 25.77d | 2009-01-05 | 2009-02-09 | 9.86d |  |
| 12 |  | Huidig opslagmechanisme doorvoeren voor Habitat | 9.33d | 2009-01-05 | 2009-01-16 | 26.29d | start no earlier than 2009-01-05 |
| 13 |  | Importeren oude projecten (XML > DB) | 11.67d | 2009-01-16 | 2009-02-02 | 14.96d | start no earlier than 2009-01-16 |
| 14 |  | Toolbox migreren naar nieuwe versie | 10.77d | 2009-01-26 | 2009-02-09 | 9.86d | start no earlier than 2009-01-26 |
| 15 | 4 | **Nieuwe functionaliteit PcRaster implementeren in Habitat** | 83d | 2008-10-01 | 2009-01-23 | 20.62d |  |
| 16 |  | Implement new GridTimeSeries data type | 15.38d | 2008-10-01 | 2008-10-22 | 88.24d | start no earlier than 2008-10-01 |
| 17 |  | Opzetten van klassen die rasterlagen laden (GDAL/NetCDF) | 7.62d | 2008-10-27 | 2008-11-05 | 78.01d | start no earlier than 2008-10-25 |
| 18 |  | Tussenresultaten facultatief opslaan | 5d | 2009-01-19 | 2009-01-23 | 20.62d | start no earlier than 2009-01-19 |
| 19 |  | Upgrade Habitat PCRaster wrapper to a time-series grids | 17.5d | 2008-12-01 | 2008-12-24 | 43.12d | start no earlier than 2008-11-30 |
| 20 |  | Upgrade all Habitat forms to a new GridTimeSeries data type | 5d | 2009-01-05 | 2009-01-09 | 31d | start no earlier than 2009-01-05 |
| 21 | 5 | **GUI controls development / upgrade** | 7.62d | 2009-01-12 | 2009-01-21 | 23d |  |
| 22 |  | Grid time series navigation (time) control | 3.2d | 2009-01-12 | 2009-01-15 | 27.43d | start no earlier than 2009-01-12 |
| 23 |  | Chart control, upgrade from Nplot to TeeChart | 2d | 2009-01-15 | 2009-01-19 | 25.25d | start no earlier than 2009-01-15 |
| 24 |  | Table control - use XtraGrid instead of standard DataGridView | 2d | 2009-01-19 | 2009-01-21 | 23d | start no earlier than 2009-01-19 |

## Version 2 (saved 2009-02-03)

Last finish 2009-02-23 → 2009-03-31 (+36d). Complete tasks 0 → 5.

Changed:

| ID | Task | Start | Finish | Duration | Complete | Total float | Other |
| --- | --- | --- | --- | --- | --- | --- | --- |
| 1 | **Map control decorations** | 2008-08-27 A | 2009-02-23 → 2009-03-05 (+10d) | 128.62d → 137d | 0% → 79% | 0d → 18d |  |
| 2 | North / south arrow | 2008-08-27 A | 2008-08-27 A |  | 0% → 100% | 127.72d → none |  |
| 3 | Cross-sectional profiles | 2008-08-28 A | 2008-09-02 → 2009-02-16 (+167d) | 3.64d → 2d | 0% → 91% | 123.99d → 31.82d | resources Paul [10%]; Arnout → Alex |
| 4 | Scale | 2008-09-02 A | 2008-09-05 A |  | 0% → 100% | 120.97d → none |  |
| 5 | Classificatie aanpassen (gui dialog) | 2009-02-09 A | 2009-02-23 → 2009-02-20 A (-3d) |  | 0% → 100% | 0d → none |  |
| 6 | Opslaan en ophalen van classificatie gegevens | 2009-02-16 → 2009-03-02 (+14d) | 2009-02-19 → 2009-03-05 (+14d) |  |  | 1.62d → 18d | constraint start no earlier than 2009-02-16 → start no earlier than 2009-03-02 |
| 7 | **Conversie applicatie voor kaartlagen (?)** | 2009-01-21 → 2009-03-02 (+40d) | 2009-02-09 → 2009-03-18 (+37d) |  |  | 10d → 9d |  |
| 8 | Uitzoeken wat werkt en niet werkt voor Resample | 2009-01-21 → 2009-03-02 (+40d) | 2009-01-23 → 2009-03-03 (+39d) |  |  | 21d → 20d | constraint start no earlier than 2009-01-21 → start no earlier than 2009-03-02 |
| 9 | Dummy proef maken | 2009-01-23 → 2009-03-02 (+38d) | 2009-01-28 → 2009-03-04 (+35d) |  |  | 18d → 19d | constraint start no earlier than 2009-01-23 → start no earlier than 2009-03-02 |
| 10 | Bug fixes + overig | 2009-01-28 → 2009-03-09 (+40d) | 2009-02-09 → 2009-03-18 (+37d) |  |  | 10d → 9d | constraint start no earlier than 2009-01-28 → start no earlier than 2009-03-09 |
| 11 | **DelftShell upgrade** | 2009-01-05 → 2009-02-02 A (+28d) | 2009-02-09 → 2009-03-02 (+21d) | 25.77d → 20.77d | 0% → 27% | 9.86d → 21.23d |  |
| 12 | Huidig opslagmechanisme doorvoeren voor Habitat | 2009-01-05 → 2009-02-02 A (+28d) | 2009-01-16 → 2009-02-13 (+28d) |  | 0% → 30% | 26.29d → 32.67d | constraint start no earlier than 2009-01-05 → start no earlier than 2009-02-02 |
| 13 | Importeren oude projecten (XML > DB) | 2009-01-16 → 2009-02-09 A (+24d) | 2009-02-02 → 2009-02-24 (+22d) |  | 0% → 50% | 14.96d → 25.33d | constraint start no earlier than 2009-01-16 → start no earlier than 2009-02-09 |
| 14 | Toolbox migreren naar nieuwe versie | 2009-01-26 → 2009-02-16 (+21d) | 2009-02-09 → 2009-03-02 (+21d) |  |  | 9.86d → 21.23d | constraint start no earlier than 2009-01-26 → start no earlier than 2009-02-16 |
| 15 | **Nieuwe functionaliteit PcRaster implementeren in Habitat** | 2008-10-01 A | 2009-01-23 → 2009-03-09 (+45d) | 83d → 113.38d | 0% → 48% | 20.62d → 16.62d |  |
| 16 | Implement new GridTimeSeries data type | 2008-10-01 A | 2008-10-22 → 2009-03-09 (+138d) | 15.38d → 10d | 0% → 46% | 88.24d → 16.62d | resources Gena [50%]; Fedor [25%] → Gena; Fedor [25%] |
| 17 | Opzetten van klassen die rasterlagen laden (GDAL/NetCDF) | 2008-10-27 A | 2008-11-05 A |  | 0% → 100% | 78.01d → none |  |
| 18 | Tussenresultaten facultatief opslaan | 2009-01-19 → 2009-02-09 (+21d) | 2009-01-23 → 2009-02-13 (+21d) |  |  | 20.62d → 32d | constraint start no earlier than 2009-01-19 → start no earlier than 2009-02-09 |
| 19 | Upgrade Habitat PCRaster wrapper to a time-series grids | 2008-12-01 A | 2008-12-24 → 2009-03-05 (+71d) |  | 0% → 50% | 43.12d → 18.25d |  |
| 20 | Upgrade all Habitat forms to a new GridTimeSeries data type | 2009-01-05 → 2009-01-26 A (+21d) | 2009-01-09 → 2009-02-20 (+42d) |  | 0% → 10% | 31d → 27.5d | constraint start no earlier than 2009-01-05 → start no earlier than 2009-01-26 |
| 21 | **GUI controls development / upgrade** | 2009-01-12 A | 2009-01-21 → 2009-03-31 (+69d) | 7.62d → 57d | 0% → 44% | 23d → 0d |  |
| 22 | Grid time series navigation (time) control | 2009-01-12 A | 2009-01-15 A |  | 0% → 100% | 27.43d → none |  |
| 23 | Chart control, upgrade from Nplot to TeeChart | 2009-01-15 → 2009-03-30 (+74d) | 2009-01-19 → 2009-03-31 (+71d) |  |  | 25.25d → 0d | constraint start no earlier than 2009-01-15 → start no earlier than 2009-03-30; resources Erik → Alex |
| 24 | Table control - use XtraGrid instead of standard DataGridView | 2009-01-19 → 2009-03-30 (+70d) | 2009-01-21 → 2009-03-31 (+69d) |  |  | 23d → 0d | constraint start no earlier than 2009-01-19 → start no earlier than 2009-03-30; resources Erik → Alex |

## Version 3 (saved 2009-02-06)

Last finish stays 2009-03-31.

Changed:

| ID | Task | Finish | Duration | Complete | Total float |
| --- | --- | --- | --- | --- | --- |
| 1 | **Map control decorations** |  |  | 79% → 71% |  |
| 3 | Cross-sectional profiles | 2009-02-16 → 2009-02-13 (-3d) | 2d → 5.64d | 91% → 50% | 31.82d → 32.36d |
